# AB-07 - met moeilijke afbouw

Schedule from MS Project, 2003-01-12 to 2003-03-12, status date 2003-01-08.
BAM Nelissen Van Egteren

## Calendars

- ALLEEN WERKDAGEN: Mon-Fri 08:30-12:30, 13:00-17:00; Sat-Sun off. Exceptions (off unless hours are given): 2003-01-11 to 2003-01-12 08:30-12:30, 13:00-17:00, 2003-01-18 to 2003-01-19 08:30-12:30, 13:00-17:00, 2003-01-25 to 2003-01-26 08:30-12:30, 13:00-17:00, 2003-02-01 to 2003-02-02 08:30-12:30, 13:00-17:00, 2003-02-08 to 2003-02-09 08:30-12:30, 13:00-17:00, 2003-02-15 to 2003-02-16 08:30-12:30, 13:00-17:00, 2003-02-22 to 2003-02-23 08:30-12:30, 13:00-17:00, 2003-03-01 to 2003-03-02 08:30-12:30, 13:00-17:00, 2003-03-08 to 2003-03-09 08:30-12:30, 13:00-17:00.

## Schedule

| ID | WBS | Task | Type | Duration | Start | Finish | Predecessors | Total slack |
| --- | --- | --- | --- | --- | --- | --- | --- | --- |
| 1 | 1 | **AFBOUWFASE** |  | 60d | 2003-01-12 | 2003-03-12 |  | 0d |
| 2 | 1.1 | **inbouwfase** |  | 26d | 2003-01-12 | 2003-02-06 |  | 0d |
| 3 | 1.1.1 | plafondleidingen vooraf | milestone | 0d | 2003-01-12 | 2003-01-12 |  | 60d |
| 4 | 1.1.2 | cementdekvloer aanbrengen |  | 4d | 2003-01-12 | 2003-01-15 |  | 0d |
| 5 | 1.1.3 | GM-wand frame monteren |  | 5d | 2003-01-16 | 2003-01-20 | 4SS+4d | 0d |
| 6 | 1.1.4 | GM-wand 1e beplating aanbr. |  | 5d | 2003-01-19 | 2003-01-23 | 5SS+3d | 0d |
| 7 | 1.1.5 | GM-wand electra leidingen+dozen |  | 5d | 2003-01-22 | 2003-01-26 | 6SS+3d | 0d |
| 8 | 1.1.6 | GM-wand water+riolering |  | 5d | 2003-01-24 | 2003-01-28 | 7SS+2d | 0d |
| 9 | 1.1.7 | GM-wand sluitwand aanbr. |  | 5d | 2003-01-27 | 2003-01-31 | 8SS+3d | 0d |
| 10 | 1.1.8 | plafond houten regelwerk |  | 5d | 2003-01-30 | 2003-02-03 | 9SS+3d | 0d |
| 11 | 1.1.9 | plafond roosters+armaturen |  | 5d | 2003-02-02 | 2003-02-06 | 10SS+3d | 34d |
| 12 | 1.2 | **afwerkingsfase** |  | 23d | 2003-02-02 | 2003-02-24 |  | 0d |
| 13 | 1.2.1 | GM-wand behangklaar maken |  | 5d | 2003-02-02 | 2003-02-06 | 10SS+3d | 0d |
| 14 | 1.2.2 | GM-wand wandafwerking |  | 5d | 2003-02-05 | 2003-02-09 | 13SS+3d | 0d |
| 15 | 1.2.3 | plafond houten latten timm. |  | 5d | 2003-02-08 | 2003-02-12 | 14SS+3d | 0d |
| 16 | 1.2.4 | plafond schilderwerk |  | 5d | 2003-02-11 | 2003-02-15 | 15SS+3d | 0d |
| 17 | 1.2.5 | wandafwerking aanbr. |  | 5d | 2003-02-14 | 2003-02-18 | 16SS+3d | 0d |
| 18 | 1.2.6 | harde vloerbedekking |  | 5d | 2003-02-17 | 2003-02-21 | 17SS+3d | 0d |
| 19 | 1.2.7 | zachte vloerbedekking |  | 5d | 2003-02-20 | 2003-02-24 | 18SS+3d | 0d |
| 20 | 1.3 | **uitrustingsfase** |  | 11d | 2003-02-23 | 2003-03-05 |  | 0d |
| 21 | 1.3.1 | binnendeuren afhangen |  | 5d | 2003-02-23 | 2003-02-27 | 19SS+3d | 0d |
| 22 | 1.3.2 | bouwkundige afmontage |  | 5d | 2003-02-25 | 2003-03-01 | 21SS+2d | 0d |
| 23 | 1.3.3 | electra afmontage |  | 5d | 2003-02-27 | 2003-03-03 | 22SS+2d | 0d |
| 24 | 1.3.4 | werktuigkundige afmontage |  | 5d | 2003-03-01 | 2003-03-05 | 23SS+2d | 0d |
| 25 | 1.3.5 | hang+sluitwerk afmonteren |  | 3d | 2003-03-02 | 2003-03-04 | 24SS+1d | 0d |

| ID | WBS | Task | Type | Duration | Start | Finish | Predecessors | Total slack |
| --- | --- | --- | --- | --- | --- | --- | --- | --- |
| 26 | 1.4 | **opleveringsfase** |  | 8d | 2003-03-05 | 2003-03-12 |  | 0d |
| 27 | 1.4.1 | vooropnemen afbouw |  | 2d | 2003-03-05 | 2003-03-06 | 25SS+3d | 0d |
| 28 | 1.4.2 | herstelwerkzaamheden |  | 5d | 2003-03-08 | 2003-03-12 | 27SS+3d | 0d |
| 29 | 1.4.3 | opleveren bouwlaag | milestone | 0d | 2003-03-12 | 2003-03-12 | 28SS+5d | 0d |
